# Management projet GI v.2007

Schedule from MS Project, 2010-09-17 to 2010-11-30, status date 2010-10-02, A marks actual dates.

## Calendars

- Standard: Mon-Fri 08:00-12:00, 13:00-17:00; Sat-Sun off.

## Resources

| Resource |
| --- |
| MACHIZAUD Andréa |
| HATIER Laurent |
| DECLERCQ Emmanuel |
| WEHRLE Geoffrey |

## Schedule

| ID | WBS | Task | Duration | Start | Finish | Predecessors | Complete | Remaining | Total slack | Free slack | Constraint | Deadline | Resources | Work | Actual work |
| --- | --- | --- | --- | --- | --- | --- | --- | --- | --- | --- | --- | --- | --- | --- | --- |
| 1 | 1 | **Livrable 1 - Analyse des besoins, réflexion de groupe** | 17d? | 2010-09-17 A | 2010-10-11 |  | 33% | 11.33d? | 35.5d |  |  |  |  | 272h | 112h |
| 2 | 1.1 | Constitution du groupe | 1d | 2010-09-17 A | 2010-09-17 |  | 99% | 0d | 51.5d |  | start no earlier than 2010-09-17 |  | HATIER Laurent; DECLERCQ Emmanuel; WEHRLE Geoffrey; MACHIZAUD Andréa | 16h | 16h |
| 3 | 1.2 | Analyse des besoins | 1d | 2010-09-24 A | 2010-09-27 A | 2 | 100% |  |  |  | start no earlier than 2010-09-24 |  | DECLERCQ Emmanuel; HATIER Laurent; MACHIZAUD Andréa; WEHRLE Geoffrey | 32h | 32h |
| 4 | 1.3 | Conception du modèle métier | 7d? | 2010-10-01 A | 2010-10-11 | 3 | 14% | 6d? | 0d |  | start no earlier than 2010-10-01 |  | DECLERCQ Emmanuel [50%]; HATIER Laurent [50%]; MACHIZAUD Andréa [50%]; WEHRLE Geoffrey [50%] | 128h | 32h |
| 5 | 1.4 | Découpage en livrables | 1d? | 2010-10-01 A | 2010-10-01 A | 3 | 100% |  |  |  | finish no earlier than 2010-10-01 |  | DECLERCQ Emmanuel; HATIER Laurent; MACHIZAUD Andréa; WEHRLE Geoffrey | 32h | 32h |
| 6 | 1.5 | Assignation des tâches | 2d? | 2010-10-04 | 2010-10-05 | 5 |  |  | 39.5d |  | finish no earlier than 2010-10-01 |  | DECLERCQ Emmanuel; HATIER Laurent; MACHIZAUD Andréa; WEHRLE Geoffrey | 64h |  |
| 7 | 2 | **Livrable 2 - Développement de l'application** | 34d | 2010-10-12 | 2010-11-26 |  |  |  | 0d |  |  |  |  | 784h |  |
| 8 | 2.1 | Développement BDD | 4d | 2010-10-12 | 2010-10-15 | 4 |  |  | 0d |  |  |  | WEHRLE Geoffrey; MACHIZAUD Andréa | 64h |  |
| 9 | 2.2 | Développement BDD avancée | 10d | 2010-11-15 | 2010-11-26 | 8 |  |  | 1.5d |  | start no earlier than 2010-11-15 |  | DECLERCQ Emmanuel; HATIER Laurent | 160h |  |
| 10 | 2.3 | **Livrable 2.1 - Développement Client** | 14d | 2010-10-20 | 2010-11-08 |  |  |  | 8.5d |  |  |  |  | 280h |  |
| 11 | 2.3.1 | Développement client (model) | 7d | 2010-10-20 | 2010-10-28 | 8FS+2d |  |  | 8.5d | 0d |  |  | HATIER Laurent; WEHRLE Geoffrey | 112h |  |
| 12 | 2.3.2 | Développement client (IHM & control) | 7d | 2010-10-20 | 2010-10-28 | 8FS+2d |  |  | 8.5d | 0d |  |  | DECLERCQ Emmanuel; MACHIZAUD Andréa | 112h |  |
| 13 | 2.3.3 | Raccord model & IHM/control | 7d | 2010-10-29 | 2010-11-08 | 12, 11 |  |  | 8.5d |  |  |  | MACHIZAUD Andréa | 56h |  |
| 14 | 2.4 | **Livrable 2.2 - Développement serveur** | 22.5d | 2010-10-20 | 2010-11-19 |  |  |  | 0d |  |  |  |  | 280h |  |
| 15 | 2.4.1 | Développement serveur (model) | 7d | 2010-10-20 | 2010-10-28 | 8FS+2d |  |  | 0d |  |  |  | MACHIZAUD Andréa; HATIER Laurent | 112h |  |
| 16 | 2.4.2 | Développement serveur (algorithme) | 10.5d | 2010-11-05 | 2010-11-19 | 15FS+5d |  |  | 0d |  | start no earlier than 2010-10-29 |  | DECLERCQ Emmanuel; WEHRLE Geoffrey | 168h |  |
| 17 | 3 | **Livrable 3 - Réseau** | 6d? | 2010-10-29 | 2010-11-05 |  |  |  | 9.5d |  |  |  |  | 192h |  |
| 18 | 3.1 | Développement communication réseau | 6d? | 2010-10-29 | 2010-11-05 | 15, 11 |  |  | 9.5d |  |  |  | DECLERCQ Emmanuel; HATIER Laurent; MACHIZAUD Andréa; WEHRLE Geoffrey | 192h |  |
| 19 | 4 | **Livrable 4 - Finalisation de l'application** | 7d? | 2010-11-19 | 2010-11-30 |  |  |  | 0d |  |  |  |  | 160h |  |
| 20 | 4.1 | Phases Tests | 5d? | 2010-11-19 | 2010-11-26 | 18, 13, 16 |  |  | 0d |  |  |  | MACHIZAUD Andréa; WEHRLE Geoffrey | 80h |  |
| 21 | 4.2 | Rédiger la documentation | 3d? | 2010-11-19 | 2010-11-24 | 13, 16, 18 |  |  | 2d |  |  | 2011-01-07 | HATIER Laurent; WEHRLE Geoffrey | 48h |  |
| 22 | 4.3 | Rédiger le rapport final | 2d | 2010-11-26 | 2010-11-30 | 20, 21 |  |  | 0d |  |  | 2011-01-07 | DECLERCQ Emmanuel; HATIER Laurent | 32h |  |

Notes:
- 2: Recherche des membres du groupe
- 3: Analyse cahier des charges, diagrammes UML, document détaillé sur les choix faits.
- 4: Objet métier principal : problème d'optimisation non linéaire / ·fonction objectif / ·contraintes d'inégalité / ·contraintes d'égalité
- 5: Grouper les futures tâches en livrables
- 6: Assigner les ressources à différentes tâches
- 8: ·Structure de la base de données / ·Jeux de tests, création de tables
- 9: ·Fonctionnalités avancées / Début des cours de BDD avancées : 15/11/10
- 11: Développer le modèle métier
- 12: Design IHM, écouteurs
- 13: Lien des classes de control avec les objets du modèle
- 15: Modélisation des problèmes, utilisateurs, droits
- 16: Développement des processus algorithmique des méthodes mathématiques
- 18: Couches réseaux, paquets, protocole / Début cours réseau : 01/11/10
- 20: Test de communication réseau, sérialisation, fonctionnalités
- 21: Documentation technique/fonctionnelle
- 22: Rapport de fin de projet
